# T1#21-T1#24-ATSrev1

Schedule from MS Project, 2003-10-27 to 2004-09-16.
Anritsu Limited

## Calendars

- Standard: Mon-Fri 08:00-12:00, 13:00-17:00; Sat-Sun off. Exceptions (off unless hours are given): 2003-12-22 to 2003-12-26, 2003-12-29 to 2004-01-02, 2004-01-17 08:00-12:00, 13:00-17:00.

## Schedule

| ID | WBS | Task | Type | Duration | Start | Finish | Predecessors | Total slack | Free slack | Constraint |
| --- | --- | --- | --- | --- | --- | --- | --- | --- | --- | --- |
| 1 | 1 | **T1#20-T1#21** |  | 27d | 2003-10-27 | 2003-12-02 |  | 34d |  |  |
| 2 | 1.1 | ATSv330 Release to reflector | milestone | 0d | 2003-10-27 | 2003-10-27 |  | 208d |  | start no earlier than 2003-10-27 |
| 3 | 1.2 | Generate IWD_2003wk43 |  | 5d | 2003-10-27 | 2003-10-31 |  | 17d | 0d | start no earlier than 2003-10-27 |
| 4 | 1.3 | IWD_2003wk43 -release to Verification Teams | milestone | 0d | 2003-10-31 | 2003-10-31 | 3 | 17d | 0d | start no earlier than 2003-10-31 |
| 5 | 1.4 | **ATSv331 - Additional Testcases** |  | 22d | 2003-11-03 | 2003-12-02 | 4 | 34d |  |  |
| 6 | 1.4.1 | TTCN CRs for new TCs |  | 10d | 2003-11-03 | 2003-11-14 |  | 17d | 0d |  |
| 7 | 1.4.2 | Generate ATSv331 |  | 2d | 2003-11-17 | 2003-11-18 | 6 | 181d | 0d |  |
| 8 | 1.4.3 | ATSv331 regression |  | 10d | 2003-11-19 | 2003-12-02 | 7 | 181d | 0d |  |
| 9 | 1.5 | ATSv331 Release to Verification Teams | milestone | 0d | 2003-12-02 | 2003-12-02 | 8 | 181d |  |  |
| 10 | 2 | **T1#21 to T1#22** |  | 62d | 2003-11-03 | 2004-02-09 |  | 39d |  |  |
| 11 | 2.1 | GCF UAG#06 |  | 2d | 2004-01-14 | 2004-01-15 |  | 176d |  | start no earlier than 2004-01-14 |
| 12 | 2.2 | T#22 Plenary |  | 3d | 2003-12-10 | 2003-12-12 |  | 185d |  | start no earlier than 2003-12-10 |
| 13 | 2.3 | T1#21 |  | 5d | 2003-11-03 | 2003-11-07 |  | 22d | 5d | start no earlier than 2003-11-03 |
| 14 | 2.4 | **ATSv340-High Priority Prose CR change only** |  | 20d | 2003-11-17 | 2003-12-12 | 13 | 34d |  |  |
| 15 | 2.4.1 | High Priority Prose CR |  | 10d | 2003-11-17 | 2003-11-28 | 6 | 17d | 0d |  |
| 16 | 2.4.2 | ATSv340 regression |  | 10d | 2003-12-01 | 2003-12-12 | 15 | 17d | 0d |  |
| 17 | 2.5 | ATSv340 release to reflector | milestone | 0d | 2003-12-12 | 2003-12-12 | 16 | 17d | 0d |  |
| 18 | 2.6 | Generate IWD_2003wk?? |  | 5d | 2003-12-15 | 2003-12-19 | 17 | 168d | 0d | start no earlier than 2003-10-27 |
| 19 | 2.7 | IWD_2003wk?? -release to Verification Teams | milestone | 0d | 2003-12-19 | 2003-12-19 | 18 | 168d |  | start no earlier than 2003-10-31 |
| 20 | 2.8 | **ATSv341 -Additional Testcases** |  | 22d | 2003-12-15 | 2004-01-26 |  | 34d |  |  |
| 21 | 2.8.1 | TTCN CRs/LP Prose CR/Dev T1#22, P1 |  | 10d | 2003-12-15 | 2004-01-09 | 17 | 7d | 0d |  |
| 22 | 2.8.2 | Generate ATSv341 |  | 2d | 2004-01-12 | 2004-01-13 | 21 | 141d | 0d |  |
| 23 | 2.8.3 | ATSv341 regression |  | 10d | 2004-01-14 | 2004-01-26 | 22 | 168d | 0d |  |
| 24 | 2.9 | ATSv341 Release to Verification Teams | milestone | 0d | 2004-01-26 | 2004-01-26 | 23 | 168d |  |  |

| ID | WBS | Task | Type | Duration | Start | Finish | Predecessors | Total slack | Free slack | Constraint |
| --- | --- | --- | --- | --- | --- | --- | --- | --- | --- | --- |
| 25 | 2.10 | **ATSv342-Additional Testcases** |  | 22d | 2004-01-12 | 2004-02-09 |  | 34d |  |  |
| 26 | 2.10.1 | TTCN CRs/LP Prose CR/Dev T1#22, P2 |  | 10d | 2004-01-12 | 2004-01-22 | 21 | 34d | 0d |  |
| 27 | 2.10.2 | ATSv342 regression |  | 10d | 2004-01-23 | 2004-02-05 | 26 | 34d | 0d |  |
| 28 | 2.10.3 | Generate ATSv342 |  | 2d | 2004-02-06 | 2004-02-09 | 27 | 34d | 0d |  |
| 29 | 2.11 | ATSv342 Release to Verification Teams | milestone | 0d | 2004-02-09 | 2004-02-09 | 28 | 34d | 0d |  |
| 30 | 3 | **T1#22-T1#23** |  | 73d | 2004-02-02 | 2004-05-12 |  | 35d |  |  |
| 31 | 3.1 | GCF UAG#07?? |  | 2d | 2004-03-15 | 2004-03-16 |  | 128d |  | start no earlier than 2004-03-15 |
| 32 | 3.2 | T#23 Plenary |  | 3d | 2004-03-10 | 2004-03-12 |  | 130d |  | start no earlier than 2004-03-10 |
| 33 | 3.3 | T1#22 |  | 5d | 2004-02-02 | 2004-02-06 |  | 19d | 2d | start no earlier than 2004-02-02 |
| 34 | 3.4 | **ATSv350-High Priority Prose CR change only** |  | 25d | 2004-02-10 | 2004-03-15 | 33 | 34d |  |  |
| 35 | 3.4.1 | High Priority Prose CR |  | 15d | 2004-02-10 | 2004-03-01 | 29 | 34d | 0d |  |
| 36 | 3.4.2 | ATSv350 regression |  | 10d | 2004-03-02 | 2004-03-15 | 35 | 34d | 0d |  |
| 37 | 3.5 | ATSv350 release to reflector | milestone | 0d | 2004-03-15 | 2004-03-15 | 36 | 34d | 0d |  |
| 38 | 3.6 | Generate IWD_2004wk?? |  | 5d | 2004-03-16 | 2004-03-22 | 37 | 128d | 0d | start no earlier than 2003-10-27 |
| 39 | 3.7 | IWD_2004wk?? -release to Verification Teams | milestone | 0d | 2004-03-22 | 2004-03-22 | 38 | 128d |  | start no earlier than 2003-10-31 |
| 40 | 3.8 | **ATSv351-Additional Testcases** |  | 27d | 2004-03-16 | 2004-04-21 |  | 34d |  |  |
| 41 | 3.8.1 | TTCN CRs/LP Prose CR/Dev T1#23, P1 |  | 15d | 2004-03-16 | 2004-04-05 | 37 | 34d | 0d |  |
| 42 | 3.8.2 | Generate ATSv351 |  | 2d | 2004-04-06 | 2004-04-07 | 41 | 106d | 0d |  |
| 43 | 3.8.3 | ATSv351 regression |  | 10d | 2004-04-08 | 2004-04-21 | 42 | 106d | 0d |  |
| 44 | 3.9 | ATSv351 Release to Verification Teams | milestone | 0d | 2004-04-21 | 2004-04-21 | 43 | 106d |  |  |
| 45 | 3.10 | **ATSv352-Additional Testcases** |  | 27d | 2004-04-06 | 2004-05-12 |  | 34d |  |  |
| 46 | 3.10.1 | TTCN CRs/LP Prose CR/Dev T1#23, P2 |  | 15d | 2004-04-06 | 2004-04-26 | 41 | 34d | 0d |  |
| 47 | 3.10.2 | Generate ATSv352 |  | 2d | 2004-04-27 | 2004-04-28 | 46 | 34d | 0d |  |
| 48 | 3.10.3 | ATSv352 regression |  | 10d | 2004-04-29 | 2004-05-12 | 47 | 34d | 0d |  |
| 49 | 3.11 | ATSv352 Release to Verification Teams | milestone | 0d | 2004-05-12 | 2004-05-12 | 48 | 34d | 0d |  |

| ID | WBS | Task | Type | Duration | Start | Finish | Predecessors | Total slack | Free slack | Constraint |
| --- | --- | --- | --- | --- | --- | --- | --- | --- | --- | --- |
| 50 | 4 | **T1#23-T1#24** |  | 60d | 2004-05-10 | 2004-07-30 |  | 34d |  |  |
| 51 | 4.1 | GCF UAG#08?? |  | 2d | 2004-06-14 | 2004-06-15 |  | 63d |  | start no earlier than 2004-06-14 |
| 52 | 4.2 | T#24 Plenary |  | 3d | 2004-06-02 | 2004-06-04 |  | 70d |  | start no earlier than 2004-06-02 |
| 53 | 4.3 | T1#23 |  | 5d | 2004-05-10 | 2004-05-14 |  | 73d |  | start no earlier than 2004-05-10 |
| 54 | 4.4 | **ATSv360-High Priority Prose CR change only** |  | 25d | 2004-05-13 | 2004-06-16 |  | 34d |  |  |
| 55 | 4.4.1 | High Priority Prose CR |  | 15d | 2004-05-13 | 2004-06-02 | 49 | 34d | 0d |  |
| 56 | 4.4.2 | ATSv360 regression |  | 10d | 2004-06-03 | 2004-06-16 | 55 | 34d | 0d |  |
| 57 | 4.5 | ATSv360 release to reflector | milestone | 0d | 2004-06-16 | 2004-06-16 | 56 | 34d | 0d |  |
| 58 | 4.6 | Generate IWD_2004wk?? |  | 5d | 2004-06-17 | 2004-06-23 | 57 | 61d | 0d | start no earlier than 2003-10-27 |
| 59 | 4.7 | IWD_2004wk?? -release to Verification Teams | milestone | 0d | 2004-06-23 | 2004-06-23 | 58 | 61d |  | start no earlier than 2003-10-31 |
| 60 | 4.8 | **ATSv361-Additional Testcases** |  | 22d | 2004-06-17 | 2004-07-16 |  | 34d |  |  |
| 61 | 4.8.1 | TTCN CRs/LP Prose CR/Dev T1#24, P1 |  | 10d | 2004-06-17 | 2004-06-30 | 57 | 34d | 0d |  |
| 62 | 4.8.2 | Generate ATSv361 |  | 2d | 2004-07-01 | 2004-07-02 | 61 | 44d | 0d |  |
| 63 | 4.8.3 | ATSv361 regression |  | 10d | 2004-07-05 | 2004-07-16 | 62 | 44d |  |  |
| 64 | 4.9 | ATSv361 release to Verification Teams | milestone | 0d | 2004-07-02 | 2004-07-02 | 62 | 54d |  |  |
| 65 | 4.10 | **ATSv362-Additional Testcases** |  | 22d | 2004-07-01 | 2004-07-30 |  | 34d |  |  |
| 66 | 4.10.1 | TTCN CRs/LP Prose CR/Dev T1#24, P1 |  | 10d | 2004-07-01 | 2004-07-14 | 61 | 34d | 0d |  |
| 67 | 4.10.2 | Generate ATSv360b (approved TCs only) |  | 2d | 2004-07-15 | 2004-07-16 | 66 | 34d | 0d |  |
| 68 | 4.10.3 | ATSv362 regression |  | 10d | 2004-07-19 | 2004-07-30 | 67 | 34d | 0d |  |
| 69 | 4.11 | ATSv362 release to Verification Teams | milestone | 0d | 2004-07-30 | 2004-07-30 | 68 | 34d |  |  |
| 70 | 5 | **T1#24-T1#25** |  | 39d | 2004-07-26 | 2004-09-16 |  | 0d |  |  |
| 71 | 5.1 | GCF UAG#09?? |  | 2d | 2004-09-15 | 2004-09-16 |  | 0d |  | start no earlier than 2004-09-15 |
| 72 | 5.2 | T#25 Plenary |  | 3d | 2004-09-08 | 2004-09-10 |  | 4d |  | start no earlier than 2004-09-08 |
| 73 | 5.3 | T1#24 |  | 5d | 2004-07-26 | 2004-07-30 |  | 18d |  | start no earlier than 2004-07-26 |
